# Target Hall shut down activities

Schedule from MS Project, 2015-02-23 to 2015-03-26, A marks actual dates.

## Calendars

- Standard: Mon-Fri 08:00-12:00, 13:00-17:00; Sat-Sun off.

## Resources

| Resource |
| --- |
| D.Wang |
| D.McDonald |
| T.Cave |
| C.Fisher |
| RPG |
| Westcoast Coring |

## Schedule

| ID | WBS | Task | Duration | Start | Finish | Predecessors | Complete | Remaining | Total slack | Free slack | Constraint | Resources | Work | Actual work |
| --- | --- | --- | --- | --- | --- | --- | --- | --- | --- | --- | --- | --- | --- | --- |
| 1 | 1 | **Pre- Module Move** | 9d | 2015-02-23 08:00 A | 2015-03-05 17:00 |  | 43% | 5.14d | 15d |  |  |  | 88h | 24h |
| 2 | 1.1 | Pedal Wheels and Coils Replacement- ITE | 1d | 2015-02-23 08:00 A | 2015-02-23 17:00 A |  | 100% |  |  |  | start no earlier than 2015-02-23 08:00 | D.Wang; D.McDonald | 8h | 8h |
| 3 | 1.2 | Storage of 6 old Turbo Pumps to Cyclotron Vault | 1d | 2015-02-24 08:00 A | 2015-02-24 17:00 A |  | 100% |  |  |  | start no earlier than 2015-02-24 08:00 | D.Wang; D.McDonald; RPG | 8h | 8h |
| 4 | 1.3 | Pedal wheels and Coils Replacement-ITW | 1d | 2015-02-25 08:00 A | 2015-02-25 17:00 A |  | 100% |  |  |  | start no earlier than 2015-02-25 08:00 | D.McDonald; D.Wang | 8h | 8h |
| 5 | 1.4 | Primary and Secondary Vacuum Vessel Leak Check-ITE | 3d | 2015-03-02 08:00 | 2015-03-04 17:00 |  |  |  | 15d |  | finish no earlier than 2015-03-04 17:00 | D.McDonald; D.Wang | 48h |  |
| 6 | 1.5 | 5 Shielding Block Move-Storage Area to ITE | 1d | 2015-03-05 08:00 | 2015-03-05 17:00 |  |  |  | 14d |  | start no earlier than 2015-03-05 08:00 | D.Wang; D.McDonald | 16h |  |
| 7 | 2 | **TM1 Move/Spent Target** | 3d | 2015-03-09 08:00 | 2015-03-11 17:00 | 6 |  |  | 2d |  |  |  | 106h |  |
| 8 | 2.1 | Cameras Set up-ITW | 0.25d | 2015-03-09 08:00 | 2015-03-09 10:00 |  |  |  | 9.5d | 0d | start no earlier than 2015-03-09 08:00 | T.Cave | 2h |  |
| 9 | 2.2 | Module Move-TM1-ITW to SHC | 0.25d | 2015-03-09 10:00 | 2015-03-09 12:00 | 8 |  |  | 9.5d | 0d | start no earlier than 2015-03-09 08:00 | D.Wang; T.Cave; D.McDonald; RPG | 8h |  |
| 10 | 2.3 | Target Removal/Electrical Check-TM1-ThO-SHC | 0.5d | 2015-03-09 13:00 | 2015-03-09 17:00 | 9 |  |  | 11d | 0d | start no earlier than 2015-03-09 08:00 | C.Fisher; T.Cave | 8h |  |
| 11 | 2.4 | Module Move-TM1-SHC to Silo | 1d | 2015-03-10 08:00 | 2015-03-10 17:00 | 10 |  |  | 11d | 0d | start no earlier than 2015-03-10 08:00 | D.Wang; T.Cave | 16h |  |
| 12 | 2.5 | Spent Target Move-ThO-SHC to Vault | 1d | 2015-03-11 08:00 | 2015-03-11 17:00 | 11 |  |  | 11d |  |  | C.Fisher; T.Cave; D.Wang | 24h |  |
| 13 | 2.6 | RPG test on TM1 ThO target | 3d | 2015-03-09 08:00 | 2015-03-11 17:00 |  |  |  | 2d | 0d | start no earlier than 2015-03-09 08:00 | RPG; D.Wang | 48h |  |
| 14 | 3 | **TM4 Move/Spent Target** | 4d | 2015-03-12 08:00 | 2015-03-17 17:00 | 13 |  |  | 2d |  |  |  | 72h |  |
| 15 | 3.1 | 5 shielding block move out of ITE/Argon Venting ITE | 0.5d | 2015-03-12 08:00 | 2015-03-12 12:00 |  |  |  | 2d | 0d | start no earlier than 2015-03-12 08:00 | D.Wang; D.McDonald | 8h |  |
| 16 | 3.2 | Cameras Set up-ITE | 0.5d | 2015-03-12 13:00 | 2015-03-12 17:00 | 15 |  |  | 2d | 0d | start no earlier than 2015-03-12 08:00 | T.Cave | 4h |  |
| 17 | 3.3 | Module Move-TM4-ITE to SHC | 0.5d | 2015-03-13 08:00 | 2015-03-13 12:00 | 16 |  |  | 2d | 0d |  | D.Wang; T.Cave; D.McDonald | 12h |  |
| 18 | 3.4 | Target Removal/Electrical Check-TM4-UCx-SHC | 0.5d | 2015-03-13 13:00 | 2015-03-13 17:00 | 17 |  |  | 2d | 0d |  | C.Fisher; T.Cave | 8h |  |
| 19 | 3.5 | Module Move-TM4 -SHC to Silo | 1d | 2015-03-16 08:00 | 2015-03-16 17:00 | 18 |  |  | 2d | 0d | start no earlier than 2015-03-13 08:00 | T.Cave; D.Wang | 16h |  |
| 20 | 3.6 | Spent Target Move-UCx-SHC to Vault | 1d | 2015-03-17 08:00 | 2015-03-17 17:00 | 19 |  |  | 2d | 0d |  | C.Fisher; T.Cave; D.Wang | 24h |  |
| 21 | 4 | **Handrail Holes Coring** | 5d | 2015-03-18 08:00 | 2015-03-24 17:00 | 20 |  |  | 2d |  |  |  | 80h |  |
| 22 | 4.1 | New Holes Coring-preparation | 2d | 2015-03-18 08:00 | 2015-03-19 17:00 |  |  |  | 2d | 0d | start no earlier than 2015-03-18 08:00 | D.Wang; D.McDonald | 32h |  |
| 23 | 4.2 | New Holes Coring-Westcoast coring | 2d | 2015-03-20 08:00 | 2015-03-23 17:00 | 22 |  |  | 2d | 0d |  | D.Wang; Westcoast Coring | 32h |  |
| 24 | 4.3 | Clean up/Re-position | 1d | 2015-03-24 08:00 | 2015-03-24 17:00 | 23 |  |  | 2d |  |  | D.Wang; D.McDonald | 16h |  |
| 25 | 5 | Leak Check -ITW BV1,BV2, and Vacuum Lines | 2d | 2015-03-25 08:00 | 2015-03-26 17:00 |  |  |  | 0d |  | start no earlier than 2015-03-25 08:00 | D.Wang; D.McDonald | 32h |  |
